# VS_ harmonogram_2

Schedule from MS Project, 2019-09-09 to 2021-10-15.

## Calendars

- Standardní: Mon-Fri 09:00-13:00, 14:00-18:00; Sat-Sun off.

## Schedule

| ID | WBS | Task | Type | Duration | Start | Finish | Predecessors | Total slack | Free slack | Constraint |
| --- | --- | --- | --- | --- | --- | --- | --- | --- | --- | --- |
| 1 | 1 | **VS II. Etapa** |  | 550d | 2019-09-09 | 2021-10-15 |  | 0d |  |  |
| 2 | 1.1 | **Výběrové řízení** |  | 125d | 2019-09-09 | 2020-02-28 |  | 380d |  |  |
| 3 | 1.1.1 | **Příprava poptávky** |  | 25d | 2019-09-09 | 2019-10-11 |  | 380d |  |  |
| 4 | 1.1.1.1 | Příprava poptávkových dokumentů, zadávací dokumenace a smlouvy |  | 20d | 2019-09-09 | 2019-10-04 |  | 380d | 0d |  |
| 5 | 1.1.1.2 | Veřejné oznámení - vyhlášení |  | 5d | 2019-10-07 | 2019-10-11 | 4 | 380d | 0d |  |
| 6 | 1.1.1.3 | Rozeslání poptávek | milestone | 0d | 2019-10-11 | 2019-10-11 | 5 | 380d | 0d |  |
| 7 | 1.1.2 | **Výběrové řízení** |  | 89d | 2019-10-14 | 2020-02-13 |  | 380d |  |  |
| 8 | 1.1.2.1 | Výběrové řízení |  | 29d | 2019-10-14 | 2019-11-21 | 6 | 380d | 0d |  |
| 9 | 1.1.2.2 | SITE návštěva č. 1 |  | 1d | 2019-10-24 | 2019-10-24 | 6SS+8d | 516d |  | start no earlier than 2019-10-24 |
| 10 | 1.1.2.3 | SITE návštěva č. 2 |  | 1d | 2019-10-31 | 2019-10-31 | 6SS+13d | 511d |  | start no earlier than 2019-10-31 |
| 11 | 1.1.2.4 | Předložení nabídek | milestone | 0d | 2019-11-21 | 2019-11-21 | 8 | 496d |  |  |
| 12 | 1.1.2.5 | Otevření obálek | milestone | 0d | 2019-11-21 | 2019-11-21 | 8 | 380d | 0d |  |
| 13 | 1.1.2.6 | **Hodnocení nabídek** |  | 21d | 2019-11-22 | 2019-12-20 |  | 380d |  |  |
| 14 | 1.1.2.6.1 | Technické a komerční hodnocení včetně kvalifikace |  | 7d | 2019-11-22 | 2019-12-02 | 12 | 380d | 0d |  |
| 15 | 1.1.2.6.2 | Vyjasnění nabídek - otázky a odpovědi |  | 9d | 2019-12-03 | 2019-12-13 | 14 | 380d | 0d |  |
| 16 | 1.1.2.6.3 | Závěrečné hodnocení - kvalifikace, technické a komerční |  | 5d | 2019-12-16 | 2019-12-20 | 15 | 380d | 0d |  |
| 17 | 1.1.2.7 | **Aukce** |  | 31d | 2020-01-02 | 2020-02-13 |  | 380d |  |  |
| 18 | 1.1.2.7.1 | Oznámení o akci - výzva |  | 5d | 2020-01-02 | 2020-01-08 | 16FS+8d | 380d | 0d |  |
| 19 | 1.1.2.7.2 | Aukce | milestone | 0d | 2020-01-09 | 2020-01-09 | 18FS+1d | 380d | 0d |  |
| 20 | 1.1.2.7.3 | Vypracování Zprávy o posouzení a hodnocení nabídek, Oznámení o výběru nejvhodnější nabídky |  | 5d | 2020-01-10 | 2020-01-16 | 19 | 380d | 0d |  |
| 21 | 1.1.2.7.4 | Zaslání Oznámení o výběru nejvhodnější nabídky uchazečům a vybranému uchazeči Žádost o součinnost pro uzavření smlouvy | milestone | 0d | 2020-01-16 | 2020-01-16 | 20 | 380d | 0d |  |
| 22 | 1.1.2.7.5 | Doba na reklamaci |  | 20d | 2020-01-17 | 2020-02-13 | 21 | 436d |  |  |
| 23 | 1.1.3 | **Smlouva** |  | 31d | 2020-01-17 | 2020-02-28 |  | 380d |  |  |
| 24 | 1.1.3.1 | Jednání o smlouvě |  | 20d | 2020-01-17 | 2020-02-13 | 21 | 380d | 0d |  |
| 25 | 1.1.3.2 | Podpis smlouvy |  | 11d | 2020-02-14 | 2020-02-28 | 24 | 380d | 0d |  |
| 26 | 1.1.3.3 | Uzavření smlouvy | milestone | 0d | 2020-02-28 | 2020-02-28 | 25 | 425d |  |  |

| ID | WBS | Task | Type | Duration | Start | Finish | Predecessors | Total slack | Free slack | Constraint |
| --- | --- | --- | --- | --- | --- | --- | --- | --- | --- | --- |
| 27 | 1.2 | **Grant** |  | 22d | 2020-03-02 | 2020-03-31 |  | 0d |  |  |
| 28 | 1.2.1 | Rozhodnutí o poskytnutí dotace | manual | 22d | 2020-03-02 | 2020-03-31 |  |  |  | start no earlier than 2020-03-02 |
| 29 | 1.3 | **Realizace** |  | 403d | 2020-03-31 | 2021-10-15 |  | 0d |  |  |
| 30 | 1.3.1 | **Realizace v roce 2020** |  | 142d | 2020-03-31 | 2020-10-15 |  | 43d |  |  |
| 31 | 1.3.1.1 | Zahájení prací, objednání a přípravných prací | milestone | 0d | 2020-03-31 | 2020-03-31 | 28, 25 | 358d | 0d |  |
| 32 | 1.3.1.2 | Přípravné práce během topné sezóny bez odstavení zařízení |  | 9w | 2020-04-01 | 2020-06-02 | 31 | 360d |  |  |
| 33 | 1.3.1.3 | Předání staveniště po odstavení zařízení - konec topné sezóny | milestone, manual | 0d | 2020-06-01 | 2020-06-01 |  |  |  | start no earlier than 2020-06-01 |
| 34 | 1.3.1.4 | Práce v roce 2020 |  | 65d | 2020-06-01 | 2020-08-28 | 33 | 261d | 0d |  |
| 35 | 1.3.1.5 | Konec odstávky 2020 | milestone | 0d | 2020-08-31 | 2020-08-31 | 34FS+1d | 294d |  |  |
| 36 | 1.3.1.6 | Mechanical completion 2020, komplexní zkoušky, předání provozu |  | 34d | 2020-08-31 | 2020-10-15 | 34 | 261d | 0d |  |
| 37 | 1.3.1.7 | Podpis protokolu Předání a převzetí - 1. část rok 2020 | milestone | 0d | 2020-10-15 | 2020-10-15 | 36 | 261d |  |  |
| 38 | 1.3.2 | **Realizace v roce 2021** |  | 99d | 2021-06-01 | 2021-10-15 |  | 0d |  |  |
| 39 | 1.3.2.1 | Předání staveniště po odstavení zařízení - konec topné sezóny | milestone, manual | 0d | 2021-06-01 | 2021-06-01 |  |  |  | start no earlier than 2021-06-01 |
| 40 | 1.3.2.2 | Práce v roce 2021 |  | 66d | 2021-06-01 | 2021-08-31 | 39 | 0d |  |  |
| 41 | 1.3.2.3 | Konec odstávky 2021 | milestone | 0d | 2021-08-31 | 2021-08-31 | 40 | 33d |  |  |
| 42 | 1.3.2.4 | Mechanical completion 2021, komplexní zkoušky, předání provozu |  | 33d | 2021-09-01 | 2021-10-15 | 40 | 0d |  |  |
| 43 | 1.3.2.5 | Podpis protokolu Předání a převzetí - 1. část rok 2021 | milestone | 0d | 2021-10-15 | 2021-10-15 | 42 | 0d |  |  |
